# ViewCVS

Schedule from MS Project, 2005-02-22 to 2005-06-09.
IBM

## Calendars

- 标准: Mon-Fri 08:00-12:00, 13:00-17:00; Sat-Sun off.

## Resources

| Resource |
| --- |
| 赵磊 |
| 鲁 |
| 赵 |
| 路 |

## Schedule

| ID | WBS | Task | Type | Duration | Start | Finish | Predecessors | Total slack | Free slack | Constraint | Resources | Work |
| --- | --- | --- | --- | --- | --- | --- | --- | --- | --- | --- | --- | --- |
| 1 | 1 | **需求分析** |  | 15d | 2005-02-22 | 2005-03-14 |  | 0d |  |  |  | 208h |
| 2 | 1.1 | **项目定义书** |  | 3d | 2005-02-22 | 2005-02-24 |  | 0d |  |  |  | 16h |
| 3 | 1.1.1 | 功能描述 |  | 2d | 2005-02-22 | 2005-02-23 |  | 0d |  |  |  |  |
| 4 | 1.1.2 | 软硬件环境 |  | 1d | 2005-02-24 | 2005-02-24 | 3 | 0d |  |  | 赵 | 8h |
| 5 | 1.1.3 | 源代码管理计划 |  | 1d | 2005-02-22 | 2005-02-22 |  | 67.75d | 0d |  | 鲁 | 8h |
| 6 | 1.2 | 环境搭建 |  | 2d | 2005-02-23 | 2005-02-24 | 5 | 67.75d | 0d | finish no earlier than 2005-02-24 | 鲁 | 16h |
| 7 | 1.3 | 文档管理计划 |  | 2d | 2005-02-25 | 2005-02-28 | 4 | 0d |  | start no earlier than 2005-02-23 | 赵 | 16h |
| 8 | 1.4 | **架构分析** |  | 9d | 2005-02-25 | 2005-03-09 |  | 2d |  |  |  | 112h |
| 9 | 1.4.1 | ViewCVS架构分析书 |  | 7d | 2005-02-25 | 2005-03-07 | 6 | 67.75d |  | start no earlier than 2005-02-24 | 鲁 | 56h |
| 10 | 1.4.2 | CVS架构分析书 |  | 7d | 2005-03-01 | 2005-03-09 | 7 | 0d |  | start no earlier than 2005-02-24 | 赵 | 56h |
| 11 | 1.5 | Proposal文档生成 |  | 2d | 2005-03-10 | 2005-03-11 | 10 | 0d |  |  | 赵; 鲁 | 32h |
| 12 | 1.6 | 需求分析Peer Review | milestone | 1d | 2005-03-14 | 2005-03-14 | 11 | 0d |  |  | 赵; 鲁 | 16h |
| 13 | 2 | **概要设计** |  | 12.75d? | 2005-03-15 | 2005-03-31 |  | 0d |  |  |  | 140h |
| 14 | 2.1 | Struts框架设计 |  | 4d | 2005-03-15 | 2005-03-18 | 12 | 58d | 0d |  | 赵 | 32h |
| 15 | 2.2 | **画面设计** |  | 3.75d | 2005-03-15 | 2005-03-18 | 12 | 0d |  |  |  | 30h |
| 16 | 2.2.1 | 画面一览 |  | 0.75d | 2005-03-15 | 2005-03-15 | 12 | 0d |  |  | 鲁 | 6h |
| 17 | 2.2.2 | 画面迁移图 |  | 3d | 2005-03-15 | 2005-03-18 | 16 | 0d |  | finish no earlier than 2005-03-03 | 鲁 | 24h |
| 18 | 2.3 | **组件列表** |  | 2d | 2005-03-18 | 2005-03-22 |  | 0d |  |  |  | 22h |
| 19 | 2.3.1 | ViewCVS组件列表 |  | 2d | 2005-03-18 | 2005-03-22 | 17 | 0d |  | start no earlier than 2005-03-02 | 鲁 | 16h |
| 20 | 2.3.2 | CVS组件列表 |  | 0.75d | 2005-03-21 | 2005-03-21 | 14 | 58d |  |  | 赵 | 6h |
| 21 | 2.4 | **数据库设计** |  | 6d | 2005-03-22 | 2005-03-30 |  | 0d |  |  |  | 48h |
| 22 | 2.4.1 | E-R图 |  | 2d | 2005-03-22 | 2005-03-24 | 19 | 0d |  |  | 赵 | 16h |
| 23 | 2.4.2 | **ViewCVS数据库设计** |  | 4d | 2005-03-24 | 2005-03-30 | 22 | 0d |  |  |  | 32h |
| 24 | 2.4.2.1 | 表设计 |  | 2d | 2005-03-24 | 2005-03-28 | 19 | 0d |  |  | 鲁 | 16h |
| 25 | 2.4.2.2 | 视图设计 |  | 2d | 2005-03-28 | 2005-03-30 | 24 | 0d |  |  | 鲁 | 16h |
| 26 | 2.5 | 数据库设计Review | milestone | 1d? | 2005-03-30 | 2005-03-31 | 25 | 0d |  |  | 赵 | 8h |

| ID | WBS | Task | Type | Duration | Start | Finish | Predecessors | Total slack | Constraint | Resources | Work |
| --- | --- | --- | --- | --- | --- | --- | --- | --- | --- | --- | --- |
| 27 | 3 | **详细设计** |  | 12d? | 2005-03-31 | 2005-04-18 |  | 0d |  |  | 192h |
| 28 | 3.1 | 用例图 |  | 2d | 2005-03-31 | 2005-04-04 | 26 | 0d |  | 赵; 鲁 | 32h |
| 29 | 3.2 | 测试计划书 |  | 2d | 2005-04-04 | 2005-04-06 | 28 | 0d | finish no earlier than 2005-04-04 | 鲁; 赵 | 32h |
| 30 | 3.3 | 时序图 |  | 3d | 2005-04-06 | 2005-04-11 | 29 | 0d |  | 赵; 鲁 | 48h |
| 31 | 3.4 | 类图 |  | 4d | 2005-04-11 | 2005-04-15 | 30 | 0d |  | 鲁; 赵 | 64h |
| 32 | 3.5 | 类图Review | milestone | 1d? | 2005-04-15 | 2005-04-18 | 31 | 0d |  | 鲁; 赵 | 16h |
| 33 | 4 | **实现** |  | 18d | 2005-04-18 | 2005-05-12 |  | 0d |  |  | 296h |
| 34 | 4.1 | 组件实现 |  | 12d | 2005-04-18 | 2005-05-04 | 32 | 0d |  | 鲁; 赵 | 192h |
| 35 | 4.2 | UT测试 |  | 3d | 2005-05-04 | 2005-05-09 | 34 | 0d |  | 鲁; 赵 | 48h |
| 36 | 4.3 | 组件集成 |  | 3d | 2005-05-09 | 2005-05-12 | 35 | 0d |  | 鲁; 赵 | 48h |
| 37 | 4.4 | ST测试用例书 |  | 1d | 2005-05-09 | 2005-05-10 | 35 | 22d |  | 赵 | 8h |
| 38 | 5 | **测试** |  | 11d | 2005-05-12 | 2005-05-27 |  | 0d |  |  | 160h |
| 39 | 5.1 | 测试管理环境搭建 |  | 2d | 2005-05-12 | 2005-05-16 | 36 | 18d |  | 赵 | 16h |
| 40 | 5.2 | 测试环境搭建 |  | 2d | 2005-05-12 | 2005-05-16 | 36 | 0d |  | 鲁 | 16h |
| 41 | 5.3 | 测试数据准备 |  | 2d | 2005-05-16 | 2005-05-18 | 40 | 0d |  | 鲁 | 16h |
| 42 | 5.4 | ST测试 | milestone | 7d | 2005-05-18 | 2005-05-27 | 41 | 0d |  | 赵; 鲁 | 112h |
| 43 | 6 | **安装** |  | 9d? | 2005-05-27 | 2005-06-09 |  | 0d |  |  | 104h |
| 44 | 6.1 | 程序打包 |  | 3d | 2005-05-27 | 2005-06-01 | 42 | 6d |  | 鲁 | 24h |
| 45 | 6.2 | 手册编写 |  | 8d | 2005-05-27 | 2005-06-08 | 42 | 0d |  | 赵 | 64h |
| 46 | 6.3 | 项目结束 |  | 1d? | 2005-06-08 | 2005-06-09 | 45 | 0d | finish no earlier than 2005-06-09 | 赵; 鲁 | 16h |
